# WBS G1

Schedule from MS Project, 2010-07-26 to 2012-01-16.

## Calendars

- Standard: Mon-Fri 08:00-12:00, 13:00-17:00; Sat-Sun off.

## Schedule

| ID | WBS | Task | Duration | Start | Finish | Predecessors | Total slack | Free slack |
| --- | --- | --- | --- | --- | --- | --- | --- | --- |
| 1 | 1 | **REKABENTUK KONVENSIONAL DALAMAN** | 386d | 2010-07-26 | 2012-01-16 |  | 0d |  |
| 2 | 1.1 | **Perancangan** | 56d | 2010-07-26 | 2010-10-11 |  | 0d |  |
| 3 | 1.1.1 | Pelantikan HODT Elektrik oleh HOPT | 1d | 2010-07-26 | 2010-07-26 |  | 0d |  |
| 4 | 1.1.2 | Penetapan HODT | 7d | 2010-07-26 | 2010-08-03 | 3SS | 0d |  |
| 5 | 1.1.3 | Maklumat pasukan rekabentuk HODT Elektrik kepada HOPT | 7d | 2010-07-26 | 2010-08-03 | 4SS | 0d |  |
| 6 | 1.1.4 | Menghadiri mesyuarat koordinasi HODT bersama HOPT | 1d | 2010-08-04 | 2010-08-04 | 5 | 0d |  |
| 7 | 1.1.5 | Penerimaan brief projek | 6d | 2010-08-04 | 2010-08-11 | 6SS | 0d |  |
| 8 | 1.1.6 | Mesyuarat Koordinasi Bil.1 | 1d | 2010-08-12 | 2010-08-12 | 7 | 0d |  |
| 9 | 1.1.7 | Penyediaan Pelan Kualiti Rekabentuk (D-Plan) | 14d | 2010-08-12 | 2010-08-31 | 8SS | 0d |  |
| 10 | 1.1.8 | Lawatan Tapak | 1d | 2010-09-01 | 2010-09-01 | 9 | 0d |  |
| 11 | 1.1.9 | Verifikasi harta pelanggan | 7d | 2010-09-02 | 2010-09-10 | 10 | 0d |  |
| 12 | 1.1.10 | Menyediakan anggaran kos projek | 7d | 2010-08-04 | 2010-08-12 | 7SS | 372d |  |
| 13 | 1.1.11 | Pengesahan brief dan skop projek oleh pelanggan | 14d | 2010-09-13 | 2010-09-30 | 11 | 330d | 0d |
| 14 | 1.1.12 | Mesyuarat skop kerja elektrik dengan pelanggan | 1d | 2010-10-01 | 2010-10-01 | 13 | 330d | 0d |
| 15 | 1.1.13 | Pengesahan skop elektrik dengan pelanggan | 7d | 2010-10-01 | 2010-10-11 | 14SS | 330d |  |
| 16 | 1.2 | **Rekabentuk** | 184d | 2010-09-13 | 2011-05-26 | 11 | 0d |  |
| 17 | 1.2.1 | Mesyuarat Koordinasi Bil.2 | 1d | 2010-09-13 | 2010-09-13 |  | 0d |  |
| 18 | 1.2.2 | Penerimaan Lukisan Senibina/Geometrik | 14d | 2010-09-14 | 2010-10-01 | 17 | 0d |  |
| 19 | 1.2.3 | **Rekabentuk Awalan** | 89d | 2010-09-14 | 2011-01-14 |  | 0d |  |
| 20 | 1.2.3.1 | Mesyuarat Koordinasi Bil.3 | 1d | 2010-10-04 | 2010-10-04 | 18 | 335d |  |
| 21 | 1.2.3.2 | Penyediaan Lukisan Awalan | 60d | 2010-09-14 | 2010-12-06 | 18SS | 288d | 0d |
| 22 | 1.2.3.3 | Mesyuarat Rekabentuk Awalan | 1d | 2010-12-07 | 2010-12-07 | 21 | 288d | 0d |
| 23 | 1.2.3.4 | Mesyuarat Koordinasi Bil.4 | 1d | 2010-12-08 | 2010-12-08 | 22 | 288d |  |
| 24 | 1.2.3.5 | Penerimaan Beban Mekanikal | 14d | 2010-09-14 | 2010-10-01 | 21SS | 329d | 0d |
| 25 | 1.2.3.6 | Pengesahan Rekabentuk Awalan dengan Pelanggan | 7d | 2010-10-04 | 2010-10-12 | 24 | 329d |  |
| 26 | 1.2.3.7 | Permohonan Anggaran Beban dan Lukisan Bangunan Pencawang TNB | 14d | 2010-09-14 | 2010-10-01 | 18SS | 322d | 0d |
| 27 | 1.2.3.8 | Kelulusan Lukisan Bangunan Pencawang dari TNB | 14d | 2010-10-04 | 2010-10-21 | 26 | 322d |  |
| 28 | 1.2.3.9 | Permohonan Kelulusan Infrastruktur TM | 14d | 2010-09-14 | 2010-10-01 | 18SS | 0d |  |
| 29 | 1.2.3.10 | Kelulusan Infrastruktur dari TM | 14d | 2010-10-04 | 2010-10-21 | 28 | 0d |  |
| 30 | 1.2.3.11 | Penerimaan Lukisan Akhir Senibina/Geometrik | 1d | 2011-01-14 | 2011-01-14 | 29FS+60d | 0d |  |

| ID | WBS | Task | Type | Duration | Start | Finish | Predecessors | Total slack |
| --- | --- | --- | --- | --- | --- | --- | --- | --- |
| 31 | 1.2.4 | **Penyediaan Rekabentuk Terperinci** |  | 94d | 2011-01-17 | 2011-05-26 |  | 0d |
| 32 | 1.2.4.1 | Mesyuarat Koordinasi Bil.5 |  | 1d | 2011-01-17 | 2011-01-17 | 30 | 0d |
| 33 | 1.2.4.2 | Penyediaan lukisan rekabentuk |  | 90d | 2011-01-18 | 2011-05-23 | 32 | 0d |
| 34 | 1.2.4.3 | Kajian semula lukisan rekabentuk |  | 1d | 2011-05-24 | 2011-05-24 | 33 | 0d |
| 35 | 1.2.4.4 | Verifikasi rekabentuk |  | 1d | 2011-05-25 | 2011-05-25 | 34 | 0d |
| 36 | 1.2.4.5 | Mesyuarat Penyelarasan (Pelanggan, HODT lain) |  | 1d | 2011-05-26 | 2011-05-26 | 35 | 0d |
| 37 | 1.3 | **Perolehan** |  | 167d | 2011-05-26 | 2012-01-13 |  | 0d |
| 38 | 1.3.1 | Penyediaan Dokumen Meja Tender |  | 5d | 2011-05-27 | 2011-06-02 | 36 | 162d |
| 39 | 1.3.2 | Mohon LO daripada HOPT |  | 14d | 2011-05-26 | 2011-06-14 | 36SS | 0d |
| 40 | 1.3.3 | **Tender** |  | 21d | 2011-06-15 | 2011-07-13 |  | 0d |
| 41 | 1.3.3.1 | Iklan Tender |  | 1d | 2011-06-15 | 2011-06-15 | 39 | 0d |
| 42 | 1.3.3.2 | Jual Tender |  | 14d | 2011-06-16 | 2011-07-05 | 41 | 0d |
| 43 | 1.3.3.3 | Tutup Tender |  | 1d | 2011-07-13 | 2011-07-13 | 42FS+5d | 0d |
| 44 | 1.3.4 | **Penilaian Tender** |  | 28d | 2011-07-14 | 2011-08-22 |  | 0d |
| 45 | 1.3.4.1 | Penyediaan Laporan Penilaian Tender |  | 21d | 2011-07-14 | 2011-08-11 | 43 | 0d |
| 46 | 1.3.4.2 | Kelulusan Lembaga Perolehan |  | 7d | 2011-08-12 | 2011-08-22 | 45 | 0d |
| 47 | 1.3.5 | **Surat Setuju Terima** |  | 104d | 2011-08-23 | 2012-01-13 |  | 0d |
| 48 | 1.3.5.1 | Pengeluaran Surat Setuju Terima kepada kontraktor |  | 14d | 2011-08-23 | 2011-09-09 | 46 | 0d |
| 49 | 1.3.5.2 | Penyediaan dan Penyerahan Dokumen Sub-Kontrak |  | 90d | 2011-09-12 | 2012-01-13 | 48 | 0d |
| 50 | 1.4 | **Pembinaan** |  | 386d | 2010-07-26 | 2012-01-16 |  | 0d |
| 51 | 1.4.1 | Mesyuarat Penyerahan Projek untuk Penyeliaan |  | 1d | 2012-01-16 | 2012-01-16 | 49 | 0d |
| 52 | 1.4.2 | Audit Pembinaan | milestone | 0d | 2010-07-26 | 2010-07-26 |  | 386d |
| 53 | 1.5 | **Penyerahan** |  | 1d | 2010-07-26 | 2010-07-26 |  | 385d |
| 54 | 1.5.1 | Audit Post Occupancy Evaluation |  | 1d | 2010-07-26 | 2010-07-26 |  | 385d |
